Schedule from Planner, 2004-09-24 to 2008-01-07.

## Calendars

- Default: Mon-Fri 08:00-12:00, 13:00-17:00; Sat-Sun off.

## Schedule

| ID | WBS | Task | Type | Duration | Start | Finish | Predecessors | Constraint | Work |
| --- | --- | --- | --- | --- | --- | --- | --- | --- | --- |
| 1 | 1 | **Commissioning** |  |  | 2004-09-24 | 2005-12-30 |  |  | 2648h |
| 2 | 1.1 | Switch ordered | milestone | 0d | 2004-09-24 | 2004-09-24 |  | must start on 2004-09-24 |  |
| 3 | 1.2 | Arrives | milestone | 0d | 2005-01-01 | 2005-01-01 | 2 | must start on 2005-01-01 |  |
| 4 | 1.3 | Nodes ordered | milestone | 0d | 2004-12-01 | 2004-12-01 |  | must start on 2004-12-01 |  |
| 5 | 1.4 | Arrives | milestone | 0d | 2005-03-01 | 2005-03-01 | 4 | must start on 2005-03-01 |  |
| 6 | 1.5 | **Stage 1** |  |  | 2005-04-01 | 2005-07-08 | 3, 5 |  | 568h |
| 7 | 1.5.1 | Step 1 |  |  | 2005-04-01 | 2005-04-07 |  | must start on 2005-04-01 | 40h |
| 8 | 1.5.2 | Step 2 |  |  | 2005-05-01 | 2005-07-08 | 7 | must start on 2005-05-01 | 400h |
| 9 | 1.6 | **Stage 2** |  |  | 2005-07-08 | 2005-11-18 | 6 |  | 760h |
| 10 | 1.6.1 | H/W maintenance |  |  | 2005-07-08 | 2005-11-18 |  |  | 760h |
| 11 | 1.7 | **Stage 3** |  |  | 2005-09-21 | 2005-12-30 |  |  | 584h |
| 12 | 1.7.1 | **1st disk lot** |  |  | 2005-09-21 | 2005-12-18 |  |  | 504h |
| 13 | 1.7.1.1 | Ordered | milestone | 0d | 2005-09-21 | 2005-09-21 |  | start no earlier than 2005-09-21 |  |
| 14 | 1.7.1.2 | Testing |  |  | 2005-11-21 | 2005-12-16 | 9, 13 | must start on 2005-11-21 | 160h |
| 15 | 1.7.1.3 | Capacity available | milestone | 0d | 2005-12-19 | 2005-12-19 | 14 | must start on 2005-12-19 |  |
| 16 | 1.7.2 | Step 2 |  |  | 2005-12-19 | 2005-12-30 | 12 | must start on 2005-12-19 | 80h |
| 17 | 2 | **Production** |  |  | 2005-12-30 | 2007-12-31 | 1 |  | 4168h |
| 18 | 2.1 | H/W maintenance |  |  | 2005-12-30 | 2007-12-28 |  |  | 4160h |
| 19 | 2.2 | First Light | milestone | 0d | 2006-01-01 | 2006-01-01 |  | must start on 2006-01-01 |  |
| 20 | 2.3 | **2nd disk lot** |  |  | 2006-06-01 | 2006-08-31 |  |  | 528h |
| 21 | 2.3.1 | Ordered | milestone | 0d | 2006-06-01 | 2006-06-01 |  | must start on 2006-06-01 |  |
| 22 | 2.3.2 | Testing |  |  | 2006-08-01 | 2006-08-28 | 21 | must start on 2006-08-01 | 160h |
| 23 | 2.3.3 | Capacity available | milestone | 0d | 2006-09-01 | 2006-09-01 | 22 | must start on 2006-09-01 |  |
| 24 | 2.4 | **3rd disk lot** |  |  | 2007-03-01 | 2007-05-31 |  |  | 528h |
| 25 | 2.4.1 | Ordered | milestone | 0d | 2007-03-01 | 2007-03-01 |  | must start on 2007-03-01 |  |
| 26 | 2.4.2 | Testing |  |  | 2007-05-01 | 2007-05-28 | 25 | must start on 2007-05-01 | 160h |
| 27 | 2.4.3 | Capacity available | milestone | 0d | 2007-06-01 | 2007-06-01 | 26 | must start on 2007-06-01 |  |
| 28 | 2.5 | End of Ref. Mission | milestone | 0d | 2008-01-01 | 2008-01-01 |  | must start on 2008-01-01 |  |

| ID | WBS | Task | Start | Finish | Predecessors | Work |
| --- | --- | --- | --- | --- | --- | --- |
| 29 | 3 | **End of Life** | 2008-01-01 | 2008-01-07 | 17 | 40h |
| 30 | 3.1 | data migration | 2008-01-01 | 2008-01-07 |  | 40h |
